# ALL

Schedule from MS Project, 2004-11-09 to 2005-03-21.

## Calendars

- Standard: Mon-Fri 08:00-12:00, 13:00-17:00; Sat-Sun off.

## Resources

| Resource |
| --- |
| Unused |
| Unassigned |
| Program Manager |
| Program Planner |
| PMO Manager |
| Practices Consultant |
| Program Sponsor |
| Program Steering Committee |
| Internal Financial Management |
| Budget Administrator |
| Facilities Administrator |
| Internal Technical Support |
| Internal Purchasing Liaison |
| Resources Administrator |
| Communications Coordinator |
| Status Tracking Coordinator |
| Project Manager |
| Technical Infrastructure Leader |
| Internal Business Change Management Leader |
| Administrative Support |
| Testing Manager |
| QA Manager |
| Risk Manager |
| Internal Business Realization Coordinator |

## Schedule

| ID | WBS | Task | Duration | Start | Finish | Predecessors | Total slack | Free slack | Constraint | Resources | Work | Text1 | Text3 | Text9 | Text2 |
| --- | --- | --- | --- | --- | --- | --- | --- | --- | --- | --- | --- | --- | --- | --- | --- |
| 1 | 1 | **SPM - Software Program Mobilization** | 37.5d | 2004-11-09 | 2004-12-30 |  | 0d |  |  |  | 623.72h | K0200000 |  |  |  |
| 2 | 1.1 | **Define Program Governance** | 4.42d | 2004-11-09 | 2004-11-15 |  | 0d |  |  |  | 86h | K0210000 |  |  |  |
| 3 | 1.1.1 | Evaluate Readiness to Begin Software Program Mobilization | 0.45d | 2004-11-09 | 2004-11-09 |  | 0d |  | must start on 2004-11-09 | Program Manager; Program Planner; PMO Manager; Practices Consultant | 12h | K0211000 | Reviewers - 2 to 4 hr^[4]4*3*1+0=12.0^ | 2^2^10/3^3^30/4^4^30/5^5^30 |  |
| 4 | 1.1.2 | Construct and Approve Program Governance Model | 0.62d | 2004-11-09 | 2004-11-10 | 3 | 1.89d | 0d |  | Program Sponsor; Program Manager; Program Planner; PMO Manager; Practices Consultant | 20h | K0212000 | Governance Roles - 4 to 6 hr^[4]4*5*1+0=20.0^ | 6^6^10/2^2^15/3^3^25/4^4^25/5^5^25 |  |
| 5 | 1.1.3 | Define Governance Principles and Organization for the Program | 1d | 2004-11-10 | 2004-11-11 | 4 | 1.89d | 0d |  | Program Sponsor; Program Manager; Program Planner; PMO Manager; Practices Consultant | 20h | K0213000 | Governance Roles - 4 to 6 hr^[4]4*5*1+0=20.0^ | 6^6^10/2^2^10/3^3^20/4^4^20/5^5^40 |  |
| 6 | 1.1.4 | Identify Program Steering Committee Members | 2.1d | 2004-11-11 | 2004-11-15 | 5 | 1.89d | 0d |  | Program Sponsor; Program Manager | 24h | K0214000 | Organizations - 2 to 4 hr^[4]8*3*1+0=24.0^ | 6^6^70/2^2^30 |  |
| 7 | 1.1.5 | Plan and Hold Initial Program Steering Committee Meeting | 0.25d | 2004-11-15 | 2004-11-15 | 5, 6 | 1.89d | 0d |  | Program Sponsor; Program Steering Committee; Program Manager; Program Planner; PMO Manager; Practices Consultant | 10h | K0215000 | Estimate as Unit - 10 hr^[4]1*10*1+0=10.0^ | 6^6^10/7^7^10/2^2^20/3^3^20/4^4^20/5^5^20 |  |
| 8 | 1.2 | **Establish the Program Management Office** | 9.66d | 2004-11-15 | 2004-11-29 |  | 1.89d |  |  |  | 151.02h | K0220000 |  |  |  |
| 9 | 1.2.1 | Define an organizational model for the Program Management Office | 1.88d | 2004-11-15 | 2004-11-17 | 5, 7 | 1.89d | 0d |  | Program Manager; PMO Manager; Practices Consultant | 30h | K0221000 | PMO Functions - 2 to 4 hr^[4]10*3*1+0=30.0^ | 2^2^25/4^4^50/5^5^25 | 10 |
| 10 | 1.2.2 | Refine and document PMO Responsibilities and individual Roles | 1.25d | 2004-11-17 | 2004-11-18 | 9 | 1.89d | 0d |  | Program Manager; PMO Manager; Practices Consultant | 20h | K0222000 | PMO Roles - 3 to 5 hr^[4]5*4*1+0=20.0^ | 2^2^25/4^4^50/5^5^25 |  |
| 11 | 1.2.3 | Develop a Program Management Office Resources Plan | 0.47d | 2004-11-18 | 2004-11-19 | 10 | 1.89d | 0d |  | Program Planner; PMO Manager; Practices Consultant | 7.52h | K0223000 | PMO Roles - 1 to 2 hr^[4]5*1.5*1+0=7.5^ | 3^3^25/4^4^50/5^5^25 |  |
| 12 | 1.2.4 | Draft the Program Management Office Resources Budget | 1.25d | 2004-11-19 | 2004-11-24 | 10, 11 | 1.89d | 0d |  | Program Manager; Program Planner; PMO Manager | 10h | K0224000 | PMO Roles - 1 to 3 hr^[4]5*2*1+0=10.0^ | 2^2^25/3^3^25/4^4^50 |  |
| 13 | 1.2.5 | Determine Decision Rights for the Program | 3.47d | 2004-11-18 | 2004-11-24 | 5, 10 | 0.62d |  |  | Program Sponsor; Program Manager; PMO Manager; Practices Consultant | 48h | K0225000 | Management Roles - 3 to 5 hr^[4]12*4*1+0=48.0^ | 6^6^10/2^2^15/4^4^50/5^5^25 | 12 |
| 14 | 1.2.6 | Prepare the Program Management Office Charter | 0.94d | 2004-11-24 | 2004-11-25 | 10, 11, 12, 13 | 1.89d | 0d |  | Program Sponsor; Program Manager; PMO Manager; Practices Consultant | 25.5h | K0226000 | PMO Functions - 2 to 4 hr^[4]10*3*1+0=30.0^ | 6^6^10/2^2^15/2^2^25/4^4^25/5^5^25 | 10 |
| 15 | 1.2.7 | Present PMO Initial Establishment Elements to the Program Steering Committee | 1.02d | 2004-11-25 | 2004-11-29 | 10, 13, 14 | 43.71d |  |  | Program Steering Committee; Program Manager; PMO Manager; Practices Consultant | 10h | K0227000 | Steering Committee Members - 1 to 3 hr^[4]5*2*1+0=10.0^ | 7^7^10/2^2^30/4^4^30/5^5^30 |  |
| 16 | 1.3 | **Define Program and Project Organization** | 5.97d | 2004-11-25 | 2004-12-03 |  | 1.33d |  |  |  | 86h | K0230000 |  |  |  |
| 17 | 1.3.1 | Prepare for Program/Projects Organizational Definition | 0.53d | 2004-11-25 | 2004-11-26 | 4, 5, 10, 14 | 1.89d | 0d |  | Program Manager; Program Planner; PMO Manager | 12h | K0231000 | Reviewers - 2 to 4 hr^[4]4*3*1+0=12.0^ | 2^2^30/3^3^35/4^4^35 |  |
| 18 | 1.3.2 | Develop Organizational Model and Program and Project Roles | 1.88d | 2004-11-26 | 2004-11-30 | 4, 14, 17 | 1.33d | 0d |  | Program Manager; PMO Manager | 24h | K0232000 | Program Functions - 2 to 4 hr^[4]8*3*1+0=24.0^ | 2^2^50/4^4^50 |  |
| 19 | 1.3.3 | Refine Organizational Models and Individual Roles | 0.8d | 2004-11-30 | 2004-12-01 | 18 | 1.33d | 0d |  | Program Sponsor; Program Manager; PMO Manager; Practices Consultant | 16h | K0233000 | Program Functions - 1 to 3 hr^[4]8*2*1+0=16.0^ | 6^6^10/2^2^10/4^4^40/5^5^40 |  |
| 20 | 1.3.4 | Amend Decision Rights Matrix for new and changed Roles | 1.8d | 2004-12-01 | 2004-12-03 | 13, 19 | 1.33d | 0d |  | Program Sponsor; Program Manager; PMO Manager; Practices Consultant | 24h | K0234000 | Management Roles - 1 to 3 hr^[4]12*2*1+0=24.0^ | 6^6^10/2^2^10/4^4^20/5^5^60 | 12 |
| 21 | 1.3.5 | Present Program and Projects Organization | 0.38d | 2004-12-03 | 2004-12-03 | 19, 20 | 1.33d | 0d |  | Program Sponsor; Program Steering Committee; Program Manager; PMO Manager; Practices Consultant | 10h | K0235000 | Steering Committee Members - 1 to 3 hr^[4]5*2*1+0=10.0^ | 6^6^10/7^7^10/2^2^20/4^4^30/5^5^30 |  |
| 22 | 1.4 | **Refine and Confirm Scope and Boundaries** | 3.67d | 2004-12-03 | 2004-12-09 |  | 1.33d |  |  |  | 94h | K0240000 |  |  |  |
| 23 | 1.4.1 | Assemble/Walkthrough Documents | 0.6d | 2004-12-03 | 2004-12-06 | 21 | 1.33d | 0d |  | Program Manager; Program Planner; PMO Manager | 12h | K0241000 | Reviewers - 2 to 4 hr^[4]4*3*1+0=12.0^ | 2^2^40/3^3^30/4^4^30 |  |
| 24 | 1.4.2 | Analyze Program Scope, Elements, and Boundaries | 0.79d | 2004-12-06 | 2004-12-06 | 23 | 1.33d | 0d |  | Program Manager; Program Planner; PMO Manager; Practices Consultant | 21h | K0242000 | Projects - 2 to 5 hr^[4]6*3.5*1+0=21.0^ | 2^2^10/3^3^30/4^4^30/5^5^30 |  |
| 25 | 1.4.3 | Quantify Program Scope and Boundary Analysis and Assess Impact | 1.12d | 2004-12-06 | 2004-12-08 | 24 | 1.33d | 0d |  | Program Manager; Program Planner; PMO Manager; Practices Consultant | 30h | K0243000 | Projects - 4 to 6 hr^[4]6*5*1+0=30.0^ | 2^2^10/3^3^30/4^4^30/5^5^30 |  |
| 26 | 1.4.4 | Develop Alternatives and Resolve Issues and Concerns | 0.41d | 2004-12-08 | 2004-12-08 | 24, 25 | 1.33d | 0d |  | Program Manager; Program Planner; PMO Manager; Practices Consultant | 11h | K0244000 | Boundary alternatives - 4 to 7 hr^[4]2*5.5*1+0=11.0^ | 2^2^10/3^3^30/4^4^30/5^5^30 |  |
| 27 | 1.4.5 | Approve revised Scope, Elements, and Boundaries | 0.75d | 2004-12-08 | 2004-12-09 | 26 | 1.33d | 0d |  | Program Sponsor; Program Steering Committee; Program Manager; Program Planner; PMO Manager; Practices Consultant | 20h | K0245000 | Steering Committee Members - 3 to 5 hr^[4]5*4*1+0=20.0^ | 6^6^10/7^7^10/2^2^20/3^3^20/4^4^10/5^5^30 |  |

| ID | WBS | Task | Duration | Start | Finish | Predecessors | Total slack | Free slack | Resources | Work | Text1 | Text2 | Text9 |
| --- | --- | --- | --- | --- | --- | --- | --- | --- | --- | --- | --- | --- | --- |
| 28 | 1.5 | **Prepare Resources Plan and Budget** | 9.62d | 2004-12-09 | 2004-12-22 |  | 1.33d |  |  | 122.7h | K0250000 |  |  |
| 29 | 1.5.1 | Review and Confirm Contents of First Program Phase | 2.19d | 2004-12-09 | 2004-12-13 | 21, 27 | 1.33d | 0d | Program Sponsor; Program Manager; Program Planner; PMO Manager | 50h | K0251000 | 10 | 6^6^15/2^2^15/3^3^35/4^4^35 |
| 30 | 1.5.2 | Map Program/Projects Roles to First Phase Contents | 1.65d | 2004-12-13 | 2004-12-15 | 19, 29 | 6.56d | 0d | Program Manager; Program Planner; PMO Manager | 16.5h | K0252000 | 11 | 2^2^20/3^3^60/4^4^20 |
| 31 | 1.5.3 | Create a Program/Projects Resources Plan | 1.24d | 2004-12-15 | 2004-12-16 | 29, 30 | 6.56d | 0d | Program Manager; Program Planner; PMO Manager | 16.5h | K0253000 | 11 | 2^2^20/3^3^60/4^4^20 |
| 32 | 1.5.4 | Update Resources Acquisition Plan with Sources | 0.86d | 2004-12-16 | 2004-12-20 | 31 | 6.56d | 0d | Program Sponsor; Program Steering Committee; Program Manager; PMO Manager | 8.2h | K0254000 | 11 | 6^6^10/7^7^10/2^2^40/4^4^40 |
| 33 | 1.5.5 | Draft Initial Program and Projects Resources Budget | 1.24d | 2004-12-20 | 2004-12-22 | 32 | 6.56d | 0d | Program Manager; Program Planner; PMO Manager | 16.5h | K0255000 | 11 | 2^2^20/3^3^60/4^4^20 |
| 34 | 1.5.6 | Approve initial Program Resources Plan and Budget | 0.75d | 2004-12-22 | 2004-12-22 | 29, 30, 31, 32, 33 | 6.56d | 0d | Program Sponsor; Program Steering Committee; Program Manager; PMO Manager | 15h | K0256000 |  | 6^6^10/7^7^10/2^2^40/4^4^40 |
| 35 | 1.6 | **Set-up Financial Management** | 5.65d | 2004-12-22 | 2004-12-30 |  | 6.99d |  |  | 84h | K0260000 |  |  |
| 36 | 1.6.1 | Assess Readiness to Initiate Financial Management | 0.75d | 2004-12-22 | 2004-12-23 | 18, 34 | 6.56d | 0d | Program Sponsor; Program Manager; PMO Manager; Internal Financial Management | 12h | K0261000 |  | 6^6^25/2^2^25/4^4^25/8^8^25 |
| 37 | 1.6.2 | Review Financial Documents and Budgets | 0.94d | 2004-12-23 | 2004-12-27 | 6, 14, 29, 34, 36 | 6.56d | 0d | Program Sponsor; Program Manager; PMO Manager; Internal Financial Management | 12h | K0262000 |  | 6^6^20/2^2^20/4^4^30/8^8^30 |
| 38 | 1.6.3 | Outline Initial Financial Management and Control Practices | 0.75d | 2004-12-27 | 2004-12-27 | 36, 37 | 6.56d | 0d | Program Sponsor; Program Manager; PMO Manager; Budget Administrator; Internal Financial Management | 24h | K0263000 |  | 6^6^10/2^2^20/4^4^20/9^9^25/8^8^25 |
| 39 | 1.6.4 | Initiate Program Financial Management Infrastructure | 0.9d | 2004-12-27 | 2004-12-29 | 36, 37, 38 | 6.56d | 0d | Program Sponsor; Program Manager; PMO Manager; Budget Administrator; Internal Financial Management | 12h | K0264000 |  | 6^6^10/2^2^15/4^4^15/9^9^30/8^8^30 |
| 40 | 1.6.5 | Update Decision Rights Matrix | 0.9d | 2004-12-29 | 2004-12-30 | 20, 38, 39 | 6.56d | 0d | Program Sponsor; Program Manager; PMO Manager; Budget Administrator; Internal Financial Management | 24h | K0265000 | 12 | 6^6^10/2^2^15/4^4^15/9^9^30/8^8^30 |
| 41 | 2 | **POI - Program Management Office Implementation** | 80.64d | 2004-11-25 | 2005-03-18 |  | 1.78d |  |  | 1464h | K0300000 |  |  |
| 42 | 2.1 | **Identify Initial Program Management Office Needs** | 19.65d | 2004-11-25 | 2004-12-23 |  | 1.32d |  |  | 137h | K0310000 |  |  |
| 43 | 2.1.1 | Review PMO Charter and Associated Documents | 1.12d | 2004-11-25 | 2004-11-26 | 13, 14 | 10.71d |  | Program Manager; PMO Manager; Practices Consultant | 12h | K0311000 |  | 2^2^20/4^4^40/5^5^40 |
| 44 | 2.1.2 | Identify Initial Services and Practices Needs | 2.25d | 2004-12-13 | 2004-12-15 | 14, 29, 43 | 1.33d | 0d | Program Manager; PMO Manager; Practices Consultant | 45h | K0312000 | 10 | 2^2^30/4^4^30/5^5^40 |
| 45 | 2.1.3 | Review and Refine Initial Staffing | 0.62d | 2004-12-15 | 2004-12-16 | 11, 12, 44 | 1.32d | 0d | Program Manager; PMO Manager | 10h | K0313000 |  | 2^2^50/4^4^50 |
| 46 | 2.1.4 | Identify Facilities and Infrastructure Needs | 2.45d | 2004-12-16 | 2004-12-21 | 14, 45 | 1.2d |  | Program Manager; PMO Manager; Facilities Administrator | 28h | K0314000 |  | 2^2^10/4^4^20/10^10^70 |
| 47 | 2.1.5 | Identify Tool and Technical Environment Needs | 3.1d | 2004-12-16 | 2004-12-22 | 14, 45 | 1.32d | 0d | Program Manager; PMO Manager; Facilities Administrator; Internal Technical Support | 32h | K0315000 |  | 2^2^30/4^4^30/10^10^30/11^11^10 |
| 48 | 2.1.6 | Integrate Needs Lists | 0.75d | 2004-12-22 | 2004-12-23 | 44, 45, 46, 47 | 1.32d | 0d | Program Sponsor; PMO Manager; Facilities Administrator; Internal Technical Support | 10h | K0316000 |  | 6^6^10/4^4^30/10^10^30/11^11^30 |
| 49 | 2.2 | **Set Initial Requirements and Implementation Strategy for the PMO** | 10.54d | 2004-12-23 | 2005-01-06 |  | 0.78d |  |  | 164h | K0320000 |  |  |
| 50 | 2.2.1 | Refine Program Management Office Needs Into Requirements | 2.25d | 2004-12-23 | 2004-12-27 | 48 | 1.32d | 0d | Program Manager; PMO Manager; Facilities Administrator; Internal Technical Support | 45h | K0321000 | 7/8 | 2^2^10/4^4^20/10^10^40/11^11^30 |
| 51 | 2.2.2 | Identify/Select PMO Choices and Products | 3.2d | 2004-12-27 | 2004-12-30 | 50 | 1.32d | 0d | Program Manager; PMO Manager; Facilities Administrator; Internal Technical Support | 64h | K0322000 | 20/12 | 2^2^10/4^4^20/10^10^30/11^11^40 |
| 52 | 2.2.3 | Review and Prioritize PMO Requirements | 1.55d | 2004-12-31 | 2005-01-04 | 50, 51 | 0.78d | 0d | Program Manager; PMO Manager; Facilities Administrator; Internal Technical Support | 18h | K0323000 |  | 2^2^10/4^4^20/10^10^30/11^11^40 |
| 53 | 2.2.4 | Identify Constraints/Limitations upon PMO Requirements | 0.59d | 2005-01-04 | 2005-01-05 | 52 | 0.78d | 0d | Program Sponsor; Program Manager; PMO Manager; Facilities Administrator; Internal Technical Support | 9h | K0324000 |  | 6^6^10/2^2^10/4^4^20/10^10^30/11^11^30 |
| 54 | 2.2.5 | Determine Initial PMO Implementation Strategy | 0.94d | 2005-01-05 | 2005-01-06 | 53 | 0.78d | 0d | Program Sponsor; Program Manager; PMO Manager; Facilities Administrator; Internal Technical Support | 18h | K0325000 |  | 6^6^10/2^2^20/4^4^20/10^10^25/11^11^25 |
| 55 | 2.2.6 | Review and Approve PMO Requirements and Implementation Strategy | 0.62d | 2005-01-06 | 2005-01-06 | 53, 54 | 0.78d | 0d | Program Sponsor; Program Manager; PMO Manager; Facilities Administrator; Internal Technical Support | 10h | K0326000 |  | 6^6^10/2^2^10/4^4^20/10^10^30/11^11^30 |

Notes:
- 29: Text3: Phase Deliverables - 4 to 6 hr^[4]10*5*1+0=50.0^
- 30: Text3: Program Selected Roles - 1 to 2 hr^[4]11*1.5*1+0=16.5^
- 31: Text3: Program Selected Roles - 1 to 2 hr^[4]11*1.5*1+0=16.5^
- 32: Text3: Program Selected Roles - 0.5 to 1 hr^[4]11*.75*1+0=8.2^
- 33: Text3: Program Selected Roles - 1 to 2 hr^[4]11*1.5*1+0=16.5^
- 34: Text3: Steering Committee Members - 2 to 4 hr^[4]5*3*1+0=15.0^
- 36: Text3: Reviewers - 2 to 4 hr^[4]4*3*1+0=12.0^
- 37: Text3: Reviewers - 2 to 4 hr^[4]4*3*1+0=12.0^
- 38: Text3: Financial Captions - 2 to 4 hr^[4]8*3*1+0=24.0^
- 39: Text3: Financial Captions - 1 to 2 hr^[4]8*1.5*1+0=12.0^
- 40: Text3: Management Roles - 1 to 3 hr^[4]12*2*1+0=24.0^
- 43: Text3: Reviewers - 2 to 4 hr^[4]4*3*1+0=12.0^
- 44: Text3: PMO Functions - 3 to 6 hr^[4]10*4.5*1+0=45.0^
- 45: Text3: PMO Roles - 1 to 3 hr^[4]5*2*1+0=10.0^
- 46: Text3: PMO Infrastructure Areas - 2 to 6 hr^[4]7*4*1+0=28.0^
- 47: Text3: PMO Environment Areas - 2 to 6 hr^[4]8*4*1+0=32.0^
- 48: Text3: Estimate as Unit - 5 to 15 hr^[4]1*10*1+0=10.0^
- 50: Text3: PMO Infrastructure Areas - 2 to 4 hr^[4]7*3*1+0=21.0^/PMO Environment Areas - 2 to 4 hr^[4]8*3*1+0=24.0^
- 51: Text3: Infrastructure Requirements - 1 to 3 hr^[4]20*2*1+0=40.0^/Technical Environment Requirements - 1 to 3 hr^[4]12*2*1+0=24.0^
- 52: Text3: Participants - 2 to 4 hr^[4]6*3*1+0=18.0^
- 53: Text3: Participants - 1 to 2 hr^[4]6*1.5*1+0=9.0^
- 54: Text3: Participants - 2 to 4 hr^[4]6*3*1+0=18.0^
- 55: Text3: Steering Committee Members - 1 to 3 hr^[4]5*2*1+0=10.0^

| ID | WBS | Task | Duration | Start | Finish | Predecessors | Total slack | Free slack | Resources | Work | Text1 | Text2 |
| --- | --- | --- | --- | --- | --- | --- | --- | --- | --- | --- | --- | --- |
| 56 | 2.3 | **Prepare Implementation Plan and Refine PMO Costs and Budget** | 20.25d | 2005-01-06 | 2005-02-04 |  | 0.78d |  |  | 97h | K0330000 |  |
| 57 | 2.3.1 | Review Program Management Office Implementation Strategy | 1.21d | 2005-01-06 | 2005-01-12 | 55 | 0.78d | 0d | Program Manager; PMO Manager; Facilities Administrator; Budget Administrator; Internal Financial Management; Internal Technical Support | 12h | K0331000 |  |
| 58 | 2.3.2 | Draft the PMO Implementation Plan | 2.25d | 2005-01-12 | 2005-01-17 | 54, 55, 57 | 0.78d | 0d | Program Manager; PMO Manager; Facilities Administrator; Budget Administrator; Internal Financial Management; Internal Technical Support | 30h | K0332000 | 10 |
| 59 | 2.3.3 | Refine PMO Costs and Prepare an Initial PMO Budget | 1.96d | 2005-01-17 | 2005-01-19 | 48, 54, 55, 58 | 0.78d | 0d | Program Manager; PMO Manager; Budget Administrator; Internal Financial Management | 24h | K0333000 |  |
| 60 | 2.3.4 | Prepare Procurement Forms and Documents | 1.99d | 2005-01-19 | 2005-01-27 | 59 | 1.2d | 0d | Program Manager; PMO Manager; Facilities Administrator; Budget Administrator; Internal Technical Support; Internal Purchasing Liaison | 21h | K0334000 |  |
| 61 | 2.3.5 | Approve PMO Implementation Plan and Updated Budget | 0.75d | 2005-01-27 | 2005-02-04 | 58, 59, 60 | 1.2d | 0d | Program Sponsor; Program Steering Committee; Program Manager; PMO Manager; Facilities Administrator; Budget Administrator; Internal Technical Support | 10h | K0335000 |  |
| 62 | 2.4 | **Complete Program Management Office Resources Acquisition** | 34.3d | 2005-01-20 | 2005-03-10 |  | 0.43d |  |  | 99.5h | K0340000 |  |
| 63 | 2.4.1 | Review Program Management Office Resources Plan and Budget | 1.27d | 2005-01-20 | 2005-01-27 | 14, 48, 59 | 0.78d | 0d | Program Manager; PMO Manager; Resources Administrator; Budget Administrator | 12h | K0341000 |  |
| 64 | 2.4.2 | Conduct Interviews for PMO Staff and Make Selections | 2.89d | 2005-01-27 | 2005-02-01 | 10, 63 | 0.78d | 0d | Program Manager; PMO Manager; Resources Administrator | 50h | K0342000 | 25 |
| 65 | 2.4.3 | Develop PMO Staff Orientation Program and Materials | 2d | 2005-01-27 | 2005-02-04 | 14, 15, 19, 64SS | 0.78d | 0d | Program Manager; PMO Manager; Resources Administrator; Practices Consultant | 16h | K0343000 |  |
| 66 | 2.4.4 | Confirm Facilities and PMO Staff Orientation Schedule | 0.94d | 2005-02-04 | 2005-02-15 | 65 | 0.43d | 0d | Program Manager; PMO Manager; Resources Administrator | 7.5h | K0344000 |  |
| 67 | 2.4.5 | Conduct PMO Staff Orientation | 1.75d | 2005-02-15 | 2005-03-10 | 65, 66 | 0.43d | 0d | Program Manager; PMO Manager; Resources Administrator | 14h | K0345000 |  |
| 68 | 2.5 | **Complete the PMO Infrastructure and Technical Environment** | 27.64d | 2005-02-04 | 2005-03-15 |  | 4.34d |  |  | 440h | K0350000 |  |
| 69 | 2.5.1 | Manage Program Management Office Product Delivery | 9.74d | 2005-02-10 | 2005-03-09 | 61 | 3.91d | 0d | Program Manager; PMO Manager; Facilities Administrator; Internal Technical Support; Internal Purchasing Liaison | 114h | K0351000 | 20/12 |
| 70 | 2.5.2 | Manage PMO Physical Facilities | 6.92d | 2005-02-04 | 2005-02-14 | 61 | 20.46d | 16.54d | Program Manager; PMO Manager; Facilities Administrator; Internal Purchasing Liaison | 80h | K0352000 | 20 |
| 71 | 2.5.3 | Manage PMO Infrastructure Set-up | 9.31d | 2005-02-09 | 2005-03-04 | 61 | 7.33d | 3.41d | Program Manager; PMO Manager; Facilities Administrator; Internal Purchasing Liaison | 80h | K0353000 | 20 |
| 72 | 2.5.4 | Manage PMO Technical Environment Installation | 8.69d | 2005-02-04 | 2005-02-16 | 61 | 18.51d | 14.59d | Program Manager; PMO Manager; Facilities Administrator; Internal Technical Support | 78h | K0354000 | 12 |
| 73 | 2.5.5 | Review and Confirm PMO Infrastructure and Environment Complete | 4.17d | 2005-03-09 | 2005-03-15 | 61, 69, 70, 71, 72 | 3.91d |  | Program Sponsor; Program Manager; PMO Manager; Facilities Administrator; Internal Technical Support; Internal Purchasing Liaison | 88h | K0355000 | 20/12 |
| 74 | 2.6 | **Develop Initial Services and Practices of the Program Management Office** | 27.39d | 2005-02-04 | 2005-03-15 |  | 1.2d |  |  | 321.5h | K0360000 |  |
| 75 | 2.6.1 | Outline/Refine Initial Program Management Office Services and Practices | 2.79d | 2005-02-04 | 2005-02-08 | 48, 54, 55, 61 | 1.2d | 0d | Program Manager; Program Planner; PMO Manager; Budget Administrator; Communications Coordinator; Status Tracking Coordinator; Facilities Administrator; Practices Consultant | 90h | K0361000 | 10/15 |
| 76 | 2.6.2 | Develop Initial PMO Services Support Materials and Environment | 3.94d | 2005-02-10 | 2005-03-04 | 75 | 1.73d | 0d | Program Manager; Program Planner; PMO Manager; Budget Administrator; Status Tracking Coordinator; Practices Consultant | 45h | K0362000 | 10 |
| 77 | 2.6.3 | Develop Initial PMO Practices Support Materials and Environment | 9.84d | 2005-02-08 | 2005-03-02 | 48, 75 | 4.54d | 2.81d | Program Manager; Program Planner; PMO Manager; Budget Administrator; Status Tracking Coordinator; Practices Consultant | 112.5h | K0363000 | 15 |
| 78 | 2.6.4 | Develop Initial Services/Practices Training Program and Materials | 3.35d | 2005-03-04 | 2005-03-10 | 76, 77 | 1.73d | 0d | Program Manager; Communications Coordinator; Practices Consultant | 64h | K0364000 |  |
| 79 | 2.6.5 | Consolidate Services, Practices, Training, and Delivery Environment | 1.25d | 2005-03-10 | 2005-03-15 | 75, 76, 77, 78 | 1.35d | 0d | Program Sponsor; Program Manager; Practices Consultant; Internal Technical Support | 10h | K0365000 |  |

Notes:
- 57: Text3: Participants - 1 to 3 hr^[4]6*2*1+0=12.0^ / Text9: 2^2^15/4^4^15/10^10^15/9^9^25/8^8^15/11^11^15
- 58: Text3: PMO Functions - 2 to 4 hr^[4]10*3*1+0=30.0^ / Text9: 2^2^10/4^4^10/10^10^20/9^9^20/8^8^20/11^11^20
- 59: Text3: Financial Captions - 2 to 4 hr^[4]8*3*1+0=24.0^ / Text9: 2^2^10/4^4^30/9^9^40/8^8^20
- 60: Text3: Suppliers - 2 to 5 hr^[4]6*3.5*1+0=21.0^ / Text9: 2^2^10/4^4^20/10^10^20/9^9^20/11^11^10/12^12^20
- 61: Text3: Steering Committee Members - 1 to 3 hr^[4]5*2*1+0=10.0^ / Text9: 6^6^10/7^7^10/2^2^10/4^4^20/10^10^20/9^9^20/11^11^10
- 63: Text3: Participants - 1 to 3 hr^[4]6*2*1+0=12.0^ / Text9: 2^2^10/4^4^30/13^13^40/9^9^20
- 64: Text3: Candidates - 1 to 3 hr^[4]25*2*1+0=50.0^ / Text9: 2^2^40/4^4^40/13^13^20
- 65: Text3: Orientation Hours - 1 to 3 hr^[4]8*2*1+0=16.0^ / Text9: 2^2^10/4^4^10/13^13^40/5^5^40
- 66: Text3: Orientation Sessions - 1 to 2 hr^[4]5*1.5*1+0=7.5^ / Text9: 2^2^10/4^4^10/13^13^80
- 67: Text3: PMO Team Members - 1 to 3 hr^[4]7*2*1+0=14.0^ / Text9: 2^2^30/4^4^30/13^13^40
- 69: Text3: Infrastructure Requirements - 2 to 4 hr^[4]20*3*1+0=60.0^/Technical Environment Requirements - 3 to 6 hr^[4]12*4.5*1+0=54.0^ / Text9: 2^2^10/4^4^20/10^10^30/11^11^20/12^12^20
- 70: Text3: Infrastructure Requirements - 3 to 5 hr^[4]20*4*1+0=80.0^ / Text9: 2^2^10/4^4^20/10^10^50/12^12^20
- 71: Text3: Infrastructure Requirements - 3 to 5 hr^[4]20*4*1+0=80.0^ / Text9: 2^2^10/4^4^20/10^10^50/12^12^20
- 72: Text3: Technical Environment Requirements - 3 to 10 hr^[4]12*6.5*1+0=78.0^ / Text9: 2^2^10/4^4^20/10^10^20/11^11^50
- 73: Text3: Infrastructure Requirements - 1 to 3 hr^[4]20*2*1+0=40.0^/Technical Environment Requirements - 3 to 5 hr^[4]12*4*1+0=48.0^ / Text9: 6^6^10/2^2^10/4^4^20/10^10^30/11^11^25/12^12^5
- 75: Text3: PMO Services - 2 to 4 hr^[4]10*3*1+0=30.0^/Practices - 3 to 5 hr^[4]15*4*1+0=60.0^ / Text9: 2^2^10/3^3^10/4^4^15/9^9^15/14^14^10/15^15^15/10^10^10/5^5^15
- 76: Text3: PMO Services - 3 to 6 hr^[4]10*4.5*1+0=45.0^ / Text9: 2^2^10/3^3^10/4^4^10/9^9^10/15^15^10/5^5^50
- 77: Text3: Practices - 5 to 10 hr^[4]15*7.5*1+0=112.5^ / Text9: 2^2^10/3^3^10/4^4^10/9^9^10/15^15^10/5^5^50
- 78: Text3: Training Areas - 8 to 24 hr^[4]4*16*1+0=64.0^ / Text9: 2^2^20/14^14^40/5^5^40
- 79: Text3: Estimate as Unit - 5 to 15 hr^[4]1*10*1+0=10.0^ / Text9: 6^6^10/2^2^20/5^5^50/11^11^20

| ID | WBS | Task | Duration | Start | Finish | Predecessors | Total slack | Free slack | Resources | Work | Text1 | Text2 |
| --- | --- | --- | --- | --- | --- | --- | --- | --- | --- | --- | --- | --- |
| 80 | 2.7 | **Implement Initial Services and Practices for the PMO** | 30.21d | 2005-02-04 | 2005-03-18 |  | 1.78d |  |  | 205h | K0370000 |  |
| 81 | 2.7.1 | Update Project Management Office Implementation Plan | 1.88d | 2005-02-04 | 2005-02-15 | 61 | 24.44d |  | Program Sponsor; Program Manager; PMO Manager; Practices Consultant | 15h | K0371000 | 10 |
| 82 | 2.7.2 | Deliver PMO Initial Services and Practices Training | 2.51d | 2005-03-10 | 2005-03-14 | 78 | 4.79d |  | Program Manager; Communications Coordinator; Practices Consultant | 28h | K0372000 |  |
| 83 | 2.7.3 | Initiate Services and Practices Supporting Technical Environment | 2.81d | 2005-03-15 | 2005-03-18 | 79 | 1.35d |  | PMO Manager; Internal Technical Support; Practices Consultant | 37.5h | K0373000 | 10/15 |
| 84 | 2.7.4 | Manage Implementation of Initial PMO Services and Practices | 12.66d | 2005-02-08 | 2005-02-28 | 61 | 6.11d | 0d | Program Manager; PMO Manager; Practices Consultant | 112.5h | K0374000 | 10/15 |
| 85 | 2.7.5 | Complete Initial PMO Implementation | 0.75d | 2005-02-28 | 2005-03-11 | 61, 84 | 6.11d |  | Program Sponsor; Program Manager; Program Planner; PMO Manager; Budget Administrator; Status Tracking Coordinator; Internal Technical Support; Practices Consultant | 12h | K0375000 |  |
| 86 | 3 | **PIE - Program Infrastructure and Environment** | 57.07d | 2004-12-30 | 2005-03-21 |  | 0.43d |  |  | 1393.9h | K0400000 |  |
| 87 | 3.1 | **Identify Infrastructure and Environment Requirements** | 5.01d | 2004-12-30 | 2005-01-06 |  | 6.99d |  |  | 163h | K0410000 |  |
| 88 | 3.1.1 | Review Program Definition Artifacts | 0.6d | 2004-12-31 | 2005-01-03 | 19, 27, 29, 40 | 54.67d |  | Program Manager; PMO Manager; Facilities Administrator; Resources Administrator; Budget Administrator; Practices Consultant; Project Manager; Technical Infrastructure Leader | 12h | K0411000 |  |
| 89 | 3.1.2 | Identify Program Infrastructure Needs | 2.1d | 2004-12-30 | 2005-01-03 | 19, 34, 40 | 6.56d | 0d | Program Manager; PMO Manager; Facilities Administrator; Resources Administrator; Budget Administrator; Practices Consultant; Project Manager; Technical Infrastructure Leader | 42h | K0412000 |  |
| 90 | 3.1.3 | Identify Program Tools and Technical Environment Needs | 1.98d | 2004-12-30 | 2005-01-03 | 19, 34, 40 | 6.84d | 0.28d | Program Manager; PMO Manager; Facilities Administrator; Project Manager; Technical Infrastructure Leader; Internal Technical Support | 48h | K0413000 |  |
| 91 | 3.1.4 | Integrate and Approve Needs List | 0.62d | 2005-01-03 | 2005-01-04 | 89, 90 | 6.56d | 0d | Program Sponsor; Program Steering Committee; Program Manager; Facilities Administrator; Practices Consultant; Project Manager; Technical Infrastructure Leader; Internal Business Change Management Leader | 10h | K0414000 |  |
| 92 | 3.1.5 | Refine Program Infrastructure Needs Into Requirements | 0.71d | 2005-01-04 | 2005-01-05 | 91 | 6.56d | 0d | Program Manager; PMO Manager; Facilities Administrator; Practices Consultant; Project Manager; Technical Infrastructure Leader; Internal Business Change Management Leader | 15h | K0415000 |  |
| 93 | 3.1.6 | Review and Prioritize Program Requirements for Infrastructure | 0.53d | 2005-01-05 | 2005-01-06 | 92 | 6.56d | 0d | Program Sponsor; Program Manager; PMO Manager; Practices Consultant; Project Manager; Internal Business Change Management Leader | 18h | K0416000 |  |
| 94 | 3.1.7 | Determine Program Initial Infrastructure Strategy | 0.45d | 2005-01-06 | 2005-01-06 | 29, 93 | 6.56d | 0d | Program Sponsor; Program Steering Committee; Program Manager; PMO Manager; Practices Consultant; Project Manager; Internal Business Change Management Leader | 18h | K0417000 |  |
| 95 | 3.2 | **Define Milestones, Components, and Costs** | 6.53d | 2005-01-06 | 2005-01-17 |  | 7.28d |  |  | 65.5h | K0420000 |  |
| 96 | 3.2.1 | Review Implementation Strategy for Infrastructure and Environment | 1.44d | 2005-01-06 | 2005-01-14 | 94 | 46.52d |  | Program Manager; Program Planner; PMO Manager; Facilities Administrator; Resources Administrator; Budget Administrator; Technical Infrastructure Leader; Internal Technical Support | 12h | K0421000 |  |
| 97 | 3.2.2 | Outline Major Milestones and Artifacts | 0.38d | 2005-01-06 | 2005-01-06 | 94 | 6.86d | 0d | Program Manager; Program Planner; PMO Manager; Facilities Administrator; Resources Administrator; Project Manager; Technical Infrastructure Leader; Internal Technical Support | 10.5h | K0422000 |  |
| 98 | 3.2.3 | Identify Major Components and Costs | 2.17d | 2005-01-06 | 2005-01-14 | 97 | 6.86d | 0d | Program Manager; Facilities Administrator; Resources Administrator; Budget Administrator; Project Manager; Technical Infrastructure Leader; Internal Technical Support; Internal Purchasing Liaison | 21h | K0423000 |  |
| 99 | 3.2.4 | Establish Program Infrastructure and Delivery Coordination Process | 0.69d | 2005-01-14 | 2005-01-17 | 97, 98 | 18.34d | 4.9d | Program Manager; Facilities Administrator; Practices Consultant; Project Manager; Technical Infrastructure Leader; Internal Purchasing Liaison | 12h | K0424000 |  |
| 100 | 3.2.5 | Approve Milestone Plan, Components, and Costs | 0.46d | 2005-01-14 | 2005-01-14 | 97, 98 | 6.86d | 0.29d | Program Sponsor; Program Steering Committee; Program Manager; Program Planner; Facilities Administrator; Project Manager; Technical Infrastructure Leader; Internal Technical Support | 10h | K0425000 |  |
| 101 | 3.3 | **Complete Initial Resources Acquisition** | 16.04d | 2005-01-06 | 2005-01-28 |  | 19.25d |  |  | 277.5h | K0430000 |  |
| 102 | 3.3.1 | Complete Consulting/Staffing Agreements | 5.38d | 2005-01-06 | 2005-01-13 | 34, 94 | 18.82d | 0d | Program Sponsor; Program Manager; PMO Manager; Resources Administrator | 105h | K0431000 |  |
| 103 | 3.3.2 | Refine Program Resources Plan and Update Resources Budget | 1.44d | 2005-01-13 | 2005-01-17 | 34, 102 | 18.82d | 0d | Program Sponsor; Program Manager; Program Planner; PMO Manager; Resources Administrator; Project Manager | 16.5h | K0432000 | 11 |
| 104 | 3.3.3 | Conduct Interviews and Make Selections | 5.62d | 2005-01-19 | 2005-01-28 | 18, 103 | 36.02d |  | Program Manager; PMO Manager; Resources Administrator; Project Manager | 50h | K0433000 | 25 |
| 105 | 3.3.4 | Develop Orientation Program and Materials | 0.8d | 2005-01-17 | 2005-01-18 | 18, 29, 40, 103 | 18.82d | 0d | Program Manager; Communications Coordinator; Practices Consultant | 16h | K0434000 |  |
| 106 | 3.3.5 | Conduct Program Orientation | 5.59d | 2005-01-18 | 2005-01-26 | 105 | 18.82d | 0d | Program Sponsor; Program Manager; PMO Manager; Administrative Support; Project Manager | 90h | K0435000 | 45 |

Notes:
- 81: Text3: PMO Functions - 1 to 2 hr^[4]10*1.5*1+0=15.0^ / Text9: 6^6^10/2^2^20/4^4^20/5^5^50
- 82: Text3: Training Days - 6 to 8 hr^[4]4*7*1+0=28.0^ / Text9: 2^2^20/14^14^20/5^5^60
- 83: Text3: PMO Services - 1 to 2 hr^[4]10*1.5*1+0=15.0^/Practices - 1 to 2 hr^[4]15*1.5*1+0=22.5^ / Text9: 4^4^10/11^11^30/5^5^60
- 84: Text3: PMO Services - 3 to 6 hr^[4]10*4.5*1+0=45.0^/Practices - 3 to 6 hr^[4]15*4.5*1+0=67.5^ / Text9: 2^2^10/4^4^30/5^5^60
- 85: Text3: Participants - 1 to 3 hr^[4]6*2*1+0=12.0^ / Text9: 6^6^10/2^2^10/3^3^10/4^4^30/9^9^10/15^15^10/11^11^10/5^5^10
- 88: Text3: Reviewers - 2 to 4 hr^[4]4*3*1+0=12.0^ / Text9: 2^2^20/4^4^20/10^10^10/13^13^10/9^9^10/5^5^10/16^16^10/17^17^10
- 89: Text3: PMO Infrastructure Areas - 4 to 8 hr^[4]7*6*1+0=42.0^ / Text9: 2^2^10/4^4^10/10^10^20/13^13^10/9^9^10/5^5^10/16^16^10/17^17^20
- 90: Text3: PMO Environment Areas - 4 to 8 hr^[4]8*6*1+0=48.0^ / Text9: 2^2^10/4^4^10/10^10^20/16^16^10/17^17^20/11^11^30
- 91: Text3: Estimate as Unit - 5 to 15 hr^[4]1*10*1+0=10.0^ / Text9: 6^6^10/7^7^10/2^2^10/10^10^20/5^5^10/16^16^10/17^17^20/18^18^10
- 92: Text3: Estimate as Unit - 10 to 20 hr^[4]1*15*1+0=15.0^ / Text9: 2^2^10/4^4^10/10^10^20/5^5^20/16^16^10/17^17^20/18^18^10
- 93: Text3: Participants - 2 to 4 hr^[4]6*3*1+0=18.0^ / Text9: 6^6^10/2^2^10/4^4^20/5^5^20/16^16^20/18^18^20
- 94: Text3: Participants - 2 to 4 hr^[4]6*3*1+0=18.0^ / Text9: 6^6^10/7^7^10/2^2^10/4^4^20/5^5^20/16^16^20/18^18^10
- 96: Text3: Reviewers - 2 to 4 hr^[4]4*3*1+0=12.0^ / Text9: 2^2^10/3^3^10/4^4^10/10^10^20/13^13^10/9^9^10/17^17^20/11^11^10
- 97: Text3: Deliverables - 1 to 2 hr^[4]7*1.5*1+0=10.5^ / Text9: 2^2^10/3^3^10/4^4^10/10^10^20/13^13^10/16^16^10/17^17^20/11^11^10
- 98: Text3: Deliverables - 2 to 4 hr^[4]7*3*1+0=21.0^ / Text9: 2^2^10/10^10^20/13^13^10/9^9^10/16^16^10/17^17^20/11^11^10/12^12^10
- 99: Text3: Organizations - 1 to 2 hr^[4]8*1.5*1+0=12.0^ / Text9: 2^2^10/10^10^25/5^5^20/16^16^10/17^17^25/12^12^10
- 100: Text3: Steering Committee Members - 1 to 3 hr^[4]5*2*1+0=10.0^ / Text9: 6^6^10/7^7^10/2^2^10/3^3^10/10^10^20/16^16^10/17^17^15/11^11^15
- 102: Text3: Suppliers - 5 to 30 hr^[4]6*17.5*1+0=105.0^ / Text9: 6^6^20/2^2^20/4^4^20/13^13^40
- 103: Text3: Program Selected Roles - 1 to 2 hr^[4]11*1.5*1+0=16.5^ / Text9: 6^6^10/2^2^10/3^3^10/4^4^10/13^13^30/16^16^30
- 104: Text3: Candidates - 1 to 3 hr^[4]25*2*1+0=50.0^ / Text9: 2^2^20/4^4^10/13^13^20/16^16^50
- 105: Text3: Orientation Hours - 1 to 3 hr^[4]8*2*1+0=16.0^ / Text9: 2^2^20/14^14^40/5^5^40
- 106: Text3: Program Team Members - 1 to 3 hr^[4]45*2*1+0=90.0^ / Text9: 6^6^10/2^2^20/4^4^20/19^19^10/16^16^40

| ID | WBS | Task | Type | Duration | Start | Finish | Predecessors | Total slack | Free slack | Constraint | Resources | Work | Text1 | Text2 |
| --- | --- | --- | --- | --- | --- | --- | --- | --- | --- | --- | --- | --- | --- | --- |
| 107 | 3.4 | **Complete the Program Infrastructure** |  | 44.18d | 2005-01-07 | 2005-03-11 |  | 6.99d |  |  |  | 387h | K0440000 |  |
| 108 | 3.4.1 | Identify Program Infrastructure Products and Facilities |  | 5.2d | 2005-01-07 | 2005-01-17 | 94 | 6.56d | 0d |  | Program Manager; PMO Manager; Facilities Administrator; Resources Administrator; Project Manager; Technical Infrastructure Leader | 70h | K0441000 | 20 |
| 109 | 3.4.2 | Refine Costs and Prepare Budget for Program Infrastructure |  | 1.2d | 2005-01-17 | 2005-01-18 | 100, 108 | 6.56d | 0d |  | Program Sponsor; Program Manager; PMO Manager; Facilities Administrator; Resources Administrator; Budget Administrator | 24h | K0442000 |  |
| 110 | 3.4.3 | Prepare the Program Infrastructure Plan |  | 2.36d | 2005-01-18 | 2005-01-20 | 97, 108, 109 | 6.56d | 0d |  | Program Manager; Program Planner; PMO Manager; Facilities Administrator; Resources Administrator; Project Manager | 42h | K0443000 |  |
| 111 | 3.4.4 | Prepare Infrastructure Procurement Forms and Documents |  | 1.92d | 2005-01-20 | 2005-02-01 | 108, 109, 110 | 6.56d | 0d |  | Program Manager; PMO Manager; Facilities Administrator; Internal Purchasing Liaison | 21h | K0444000 |  |
| 112 | 3.4.5 | Manage/Coordinate Delivery of Components and Products |  | 3.15d | 2005-02-01 | 2005-02-04 | 99, 110, 111 | 6.56d | 0d |  | Program Manager; PMO Manager; Facilities Administrator; Project Manager; Internal Purchasing Liaison | 60h | K0445000 | 20 |
| 113 | 3.4.6 | Manage Program Infrastructure Installation and Set-up |  | 10.79d | 2005-02-04 | 2005-02-23 | 99, 110, 111, 112 | 6.56d | 0d |  | Program Manager; PMO Manager; Facilities Administrator; Project Manager; Internal Purchasing Liaison | 130h | K0446000 | 20 |
| 114 | 3.4.7 | Confirm Program Infrastructure Complete |  | 2.97d | 2005-02-23 | 2005-03-11 | 110, 111, 113 | 6.56d |  |  | Program Sponsor; Program Manager; Program Planner; PMO Manager; Facilities Administrator; Project Manager | 40h | K0447000 | 20 |
| 115 | 3.5 | **Implement the Technical Environment** |  | 19.95d | 2005-01-06 | 2005-02-03 |  | 24.77d |  |  |  | 311.2h | K0450000 |  |
| 116 | 3.5.1 | Define Program Technical Environment and Components |  | 2.09d | 2005-01-06 | 2005-01-12 | 94 | 24.34d | 0d |  | Program Manager; PMO Manager; Project Manager; Technical Infrastructure Leader; Testing Manager; QA Manager; Internal Technical Support | 42h | K0451000 | 12 |
| 117 | 3.5.2 | Prepare a Budget and Arrange Procurement |  | 2.1d | 2005-01-18 | 2005-01-21 | 109, 116 | 21.68d | 0.6d |  | Program Sponsor; Program Steering Committee; Program Manager; PMO Manager; Budget Administrator; Technical Infrastructure Leader; Internal Financial Management; Internal Technical Support | 24h | K0452000 |  |
| 118 | 3.5.3 | Prepare Technical Environment Installation Plan |  | 2.51d | 2005-01-18 | 2005-01-21 | 109, 116 | 32.11d | 0d |  | Program Manager; Program Planner; PMO Manager; Facilities Administrator; Technical Infrastructure Leader; Internal Technical Support; Internal Purchasing Liaison | 43.2h | K0453000 |  |
| 119 | 3.5.4 | Create Tools Policies Descriptions/Usage Procedures |  | 3d | 2005-01-12 | 2005-01-17 | 116 | 24.34d | 0.76d |  | Program Manager; PMO Manager; Practices Consultant; Technical Infrastructure Leader; Testing Manager; QA Manager; Internal Technical Support | 70h | K0454000 |  |
| 120 | 3.5.5 | Manage/Coordinate the Technical Environment Installation |  | 5.09d | 2005-01-21 | 2005-02-02 | 99, 117, 118, 119 | 32.78d |  |  | Program Manager; PMO Manager; Project Manager; Technical Infrastructure Leader; Internal Technical Support; Internal Purchasing Liaison | 78h | K0455000 | 12 |
| 121 | 3.5.6 | Validate Technical Environment Installation Complete |  | 4.05d | 2005-01-21 | 2005-02-03 | 97, 116, 117, 118 | 32.11d |  |  | Program Manager; PMO Manager; Project Manager; Technical Infrastructure Leader; Testing Manager; QA Manager; Internal Technical Support | 54h | K0456000 | 12 |
| 122 | 3.6 | **Initiate Impact and Risk Assessment** |  | 7.56d | 2005-03-10 | 2005-03-21 |  | 0.43d |  |  |  | 95.7h | K0460000 |  |
| 123 | 3.6.1 | Refine Roles and Responsibilities to Include Impact and Risk Assessment |  | 1.4d | 2005-03-10 | 2005-03-16 | 67, 40 | 0.43d | 0d |  | Program Sponsor; Program Manager; PMO Manager; Practices Consultant; Risk Manager; Internal Business Change Management Leader; Internal Business Realization Coordinator | 33h | K0461000 | 11 |
| 124 | 3.6.2 | Create Impact and Risk Goals, Milestones, and Deliverables Plan |  | 0.39d | 2005-03-16 | 2005-03-16 | 123 | 0.43d | 0d |  | Program Manager; Program Planner; PMO Manager; Risk Manager; Internal Business Change Management Leader; Internal Business Realization Coordinator | 10.5h | K0462000 |  |
| 125 | 3.6.3 | Define Organizational Change Management Strategy |  | 1.35d | 2005-03-16 | 2005-03-21 | 19, 27, 29, 40, 123, 124 | 0.45d |  |  | Program Sponsor; Program Steering Committee; Program Manager; Practices Consultant; Risk Manager; Internal Business Change Management Leader | 16.2h | K0463000 |  |
| 126 | 3.6.4 | Define Benefits Realization Strategy |  | 1.35d | 2005-03-16 | 2005-03-21 | 123, 124 | 0.43d |  |  | Program Sponsor; Program Steering Committee; Program Manager; Program Planner; Practices Consultant; Risk Manager; Internal Business Realization Coordinator | 18h | K0464000 |  |
| 127 | 3.6.5 | Define Program Level Risk Management Strategy |  | 1.35d | 2005-03-16 | 2005-03-18 | 27, 29, 123, 124 | 0.9d |  |  | Program Sponsor; Program Steering Committee; Program Manager; Program Planner; Practices Consultant; Risk Manager | 18h | K0465000 |  |
| 128 | 3.7 | **Plan and Deliver Training** |  | 25.94d | 2005-01-17 | 2005-02-22 |  | 19.25d |  |  |  | 94h | K0470000 |  |
| 129 | 3.7.1 | Define and Prioritize Immediate Program Training Needs |  | 1.5d | 2005-01-17 | 2005-01-19 | 14, 103, 108, 116, 119 | 23.59d | 4.76d |  | Program Manager; PMO Manager; Resources Administrator; Project Manager; Technical Infrastructure Leader | 24h | K0471000 |  |
| 130 | 3.7.2 | Develop the Program's Training Program, Materials, and Budget |  | 2.27d | 2005-01-26 | 2005-02-03 | 103, 109, 117, 129, 106 | 18.82d | 0d |  | Program Manager; PMO Manager; Resources Administrator; Budget Administrator; Project Manager | 24h | K0472000 |  |
| 131 | 3.7.3 | Identify and Confirm Facilities and Schedule for Training Program |  | 1.05d | 2005-02-03 | 2005-02-07 | 130 | 18.82d | 0d |  | Program Manager; PMO Manager; Resources Administrator; Project Manager | 12h | K0473000 |  |
| 132 | 3.7.4 | Deliver/Execute the Training Program |  | 2.75d | 2005-02-07 | 2005-02-22 | 131 | 18.82d | 0d |  | Program Manager; PMO Manager; Resources Administrator; Budget Administrator; Project Manager; Technical Infrastructure Leader | 28h | K0474000 |  |
| 133 | 3.7.5 | Assess Training Program Results and Identify Additional Needs |  | 0.3d | 2005-02-22 | 2005-02-22 | 130, 132 | 18.82d |  |  | Program Manager; Resources Administrator; Budget Administrator; Project Manager; Technical Infrastructure Leader | 6h | K0475000 |  |
| 134 | 4 | Inception Completion | milestone | 0d | 2004-12-03 | 2004-12-03 |  | 0d |  | must finish on 2004-12-03 |  |  |  |  |
| 135 | 5 | Elaboration Completion | milestone | 0d | 2005-01-06 | 2005-01-06 |  | 0d |  | must finish on 2005-01-06 |  |  |  |  |
| 136 | 6 | Construction Completion | milestone | 0d | 2005-03-04 | 2005-03-04 |  | 0d |  | must finish on 2005-03-04 |  |  |  |  |
| 137 | 7 | Transition Completion | milestone | 0d | 2005-03-21 | 2005-03-21 |  | 0d |  | must finish on 2005-03-21 |  |  |  |  |

Notes:
- 108: Text3: Infrastructure Requirements - 2 to 5 hr^[4]20*3.5*1+0=70.0^ / Text9: 2^2^10/4^4^20/10^10^20/13^13^10/16^16^20/17^17^20
- 109: Text3: Financial Captions - 2 to 4 hr^[4]8*3*1+0=24.0^ / Text9: 6^6^10/2^2^10/4^4^20/10^10^10/13^13^10/9^9^40
- 110: Text3: PMO Infrastructure Areas - 4 to 8 hr^[4]7*6*1+0=42.0^ / Text9: 2^2^10/3^3^20/4^4^25/10^10^25/13^13^10/16^16^10
- 111: Text3: Suppliers - 2 to 5 hr^[4]6*3.5*1+0=21.0^ / Text9: 2^2^10/4^4^20/10^10^40/12^12^30
- 112: Text3: Infrastructure Requirements - 2 to 4 hr^[4]20*3*1+0=60.0^ / Text9: 2^2^10/4^4^10/10^10^40/16^16^20/12^12^20
- 113: Text3: Infrastructure Requirements - 3 to 10 hr^[4]20*6.5*1+0=130.0^ / Text9: 2^2^10/4^4^30/10^10^30/16^16^20/12^12^10
- 114: Text3: Infrastructure Requirements - 1 to 3 hr^[4]20*2*1+0=40.0^ / Text9: 6^6^10/2^2^10/3^3^20/4^4^20/10^10^20/16^16^20
- 116: Text3: Technical Environment Requirements - 2 to 5 hr^[4]12*3.5*1+0=42.0^ / Text9: 2^2^10/4^4^10/16^16^20/17^17^20/20^20^10/21^21^10/11^11^20
- 117: Text3: Financial Captions - 2 to 4 hr^[4]8*3*1+0=24.0^ / Text9: 6^6^10/7^7^10/2^2^10/4^4^20/9^9^20/17^17^10/8^8^10/11^11^10
- 118: Text3: PMO Environment Areas - 4 to 8 hr^[4]8*6*1+0=48.0^ / Text9: 2^2^10/3^3^10/4^4^10/10^10^10/2^2^10/17^17^20/11^11^20/12^12^10
- 119: Text3: Modelling/Development Tools - 4 to 16 hr^[4]7*10*1+0=70.0^ / Text9: 2^2^10/4^4^10/5^5^30/17^17^15/20^20^10/21^21^10/11^11^15
- 120: Text3: Technical Environment Requirements - 3 to 10 hr^[4]12*6.5*1+0=78.0^ / Text9: 2^2^10/4^4^10/16^16^10/17^17^30/11^11^30/12^12^10
- 121: Text3: Technical Environment Requirements - 3 to 6 hr^[4]12*4.5*1+0=54.0^ / Text9: 2^2^10/4^4^10/16^16^10/17^17^30/20^20^10/21^21^10/11^11^20
- 123: Text3: Program Selected Roles - 2 to 4 hr^[4]11*3*1+0=33.0^ / Text9: 6^6^10/2^2^10/4^4^10/5^5^10/22^22^20/18^18^20/23^23^20
- 124: Text3: Deliverables - 1 to 2 hr^[4]7*1.5*1+0=10.5^ / Text9: 2^2^10/3^3^20/4^4^10/22^22^20/18^18^20/23^23^20
- 125: Text3: Participants - 2 to 4 hr^[4]6*3*1+0=18.0^ / Text9: 6^6^10/7^7^10/2^2^10/2^2^10/5^5^20/22^22^10/18^18^30
- 126: Text3: Participants - 2 to 4 hr^[4]6*3*1+0=18.0^ / Text9: 6^6^10/7^7^10/2^2^10/3^3^10/5^5^20/22^22^10/23^23^30
- 127: Text3: Participants - 2 to 4 hr^[4]6*3*1+0=18.0^ / Text9: 6^6^10/7^7^10/2^2^10/3^3^10/5^5^20/22^22^40
- 129: Text3: Training Areas - 4 to 8 hr^[4]4*6*1+0=24.0^ / Text9: 2^2^10/4^4^10/13^13^30/16^16^20/17^17^30
- 130: Text3: Training Areas - 4 to 8 hr^[4]4*6*1+0=24.0^ / Text9: 2^2^10/4^4^10/13^13^40/9^9^20/16^16^20
- 131: Text3: Training Sessions - 4 to 8 hr^[4]2*6*1+0=12.0^ / Text9: 2^2^10/4^4^10/13^13^60/16^16^20
- 132: Text3: Training Days - 6 to 8 hr^[4]4*7*1+0=28.0^ / Text9: 2^2^10/4^4^10/13^13^40/9^9^20/16^16^10/17^17^10
- 133: Text3: Training Sessions - 2 to 4 hr^[4]2*3*1+0=6.0^ / Text9: 2^2^10/13^13^40/9^9^10/16^16^20/17^17^20
